# Residential Construction 13

How a schedule from MS Project changed from version to version. A marks actual dates.

## Version 1 (saved 2017-11-24, file Residential Construction.mpp)

| ID | WBS | Task | Duration | Start | Finish | Predecessors | Complete | Total float |
| --- | --- | --- | --- | --- | --- | --- | --- | --- |
| 1 | 1 | **General Conditions** | 16d | 2016-09-05 A | 2016-09-26 |  | 33% | 0d |
| 2 |  | Complete plans and develop estimate with owner, architect | 3w | 2016-09-05 A | 2016-09-23 |  | 33% | 0.25d |
| 3 |  | Sign contract and notice to proceed | 1d | 2016-09-26 A | 2016-09-26 | 2 | 25% | -0.75d |
| 4 | 1.3 | **Apply for Permits** | 0d | 2016-09-26 | 2016-09-26 |  |  | -0.75d |
| 5 |  | Secure foundaton permit | 0d | 2016-09-26 | 2016-09-26 | 3 |  | -0.75d |
| 6 |  | Secure framing permit | 0d | 2016-09-26 | 2016-09-26 | 3 |  | -0.75d |
| 7 |  | Secure electrical permit | 0d | 2016-09-26 | 2016-09-26 | 3 |  | -0.75d |
| 8 |  | Secure plumbing permit | 0d | 2016-09-26 | 2016-09-26 | 3 |  | -0.75d |
| 9 |  | Secure HVAC permit | 0d | 2016-09-26 | 2016-09-26 | 3 |  | -0.75d |
| 10 |  | Secure miscellaneous permits | 0d | 2016-09-26 | 2016-09-26 | 3 |  | -0.75d |
| 11 | 2 | **Site Work** | 2.75d | 2016-09-27 | 2016-09-29 |  |  | -0.75d |
| 12 |  | Clear site | 1d | 2016-09-27 | 2016-09-27 | 5, 6, 7, 8, 9, 10 |  | -0.75d |
| 13 |  | Install temporary power service | 6h | 2016-09-28 | 2016-09-28 | 12 |  | -0.75d |
| 14 |  | Install underground utilities | 1d | 2016-09-28 | 2016-09-29 | 13 |  | -0.75d |
| 15 | 3 | **Foundation** | 13.25d | 2016-09-29 | 2016-10-18 |  |  | -0.75d |
| 16 |  | Excavate for foundations | 3d | 2016-09-29 | 2016-10-04 | 14 |  | -0.75d |
| 17 |  | Form basement walls | 13d | 2016-10-04 | 2016-10-08 | 16 |  | -0.75d |
| 18 |  | Pour concrete for foundations & basement walls | 12d | 2016-10-08 | 2016-10-12 | 17 |  | -1d |
| 19 |  | Strip basement wall forms | 2d | 2016-10-12 | 2016-10-13 | 18 |  | -1d |
| 20 |  | Waterproof/insulate basement walls | 2d | 2016-10-13 | 2016-10-14 | 19 |  | -0.75d |
| 21 |  | Perform foundation inspection | 1d | 2016-10-14 | 2016-10-14 | 20, 16 |  | -0.25d |
| 22 |  | Backfill foundation | 2d | 2016-10-17 | 2016-10-18 | 21 |  | -0.25d |
| 23 | 4 | **Framing** | 21.75d | 2016-10-19 | 2016-11-17 |  |  | -0.25d |
| 24 |  | Install 1st floor joists | 2d | 2016-10-19 | 2016-10-20 | 22 |  | -0.25d |
| 25 |  | Lay 1st floor decking | 2d | 2016-10-21 | 2016-10-24 | 24 |  | -0.25d |
| 26 |  | Frame 1st floor walls | 4d | 2016-10-25 | 2016-10-28 | 25 |  | -0.25d |
| 27 |  | Frame 1st floor corners | 1d | 2016-10-31 | 2016-10-31 | 26 |  | -0.25d |
| 28 |  | Install 2nd floor joists | 2d | 2016-11-01 | 2016-11-02 | 27 |  | -0.25d |
| 29 |  | Frame 2nd floor decking | 2d | 2016-11-03 | 2016-11-04 | 28 |  | -0.25d |
| 30 |  | Frame 2nd floor walls | 3d | 2016-11-07 | 2016-11-09 | 29 |  | -0.25d |
| 31 |  | Frame 2nd floor corners | 2d | 2016-11-10 | 2016-11-11 | 30 |  | -0.25d |
| 32 |  | Complete roof framing | 3d | 2016-11-14 | 2016-11-16 | 31 |  | -0.25d |
| 33 |  | Conduct framing inspection | 6h | 2016-11-17 | 2016-11-17 | 32 |  | -0.25d |
| 34 | 5 | **Dry In** | 21.75d | 2016-11-17 | 2016-12-16 |  |  | -0.25d |
| 35 |  | Install 1st floor sheathing | 3d | 2016-11-17 | 2016-11-22 | 33 |  | -0.25d |
| 36 |  | Install 2nd floor sheathing | 3d | 2016-11-22 | 2016-11-25 | 35 |  | -0.25d |
| 37 |  | Install roof decking | 3d | 2016-11-17 | 2016-11-21 | 32 |  | 3.5d |
| 38 |  | Install felt, flashing and shingles | 3d | 2016-12-02 | 2016-12-07 | 46 |  | -0.25d |
| 39 |  | Hang 1st floor exterior doors | 1d | 2016-12-07 | 2016-12-08 | 38 |  | -0.25d |
| 40 |  | Install 1st floor windows | 3d | 2016-12-08 | 2016-12-13 | 39 |  | -0.25d |
| 41 |  | Install 2nd floor windows | 3d | 2016-12-13 | 2016-12-16 | 40 |  | -0.25d |
| 42 | 6 | **Exterior Finishes** | 13d | 2016-12-16 | 2017-01-04 |  |  | 12.25d |
| 43 |  | Complete exterior brick | 2w | 2016-12-16 | 2016-12-30 | 41 |  | 12.25d |
| 44 |  | Complete exterior siding | 3d | 2016-12-30 | 2017-01-04 | 43 |  | 12.25d |
| 45 | 7 | **Utility Rough-Ins and Complete Concrete** | 13.75d | 2016-11-22 | 2016-12-09 |  |  | 3.5d |
| 46 |  | Rough-in plumbing | 5d | 2016-11-25 | 2016-12-02 | 37, 36 |  | -0.25d |
| 47 |  | Conduct rough-in plumbing inspection | 1d | 2016-12-02 | 2016-12-05 | 46 |  | 19.75d |
| 48 |  | Place concrete for basement floor | 2w | 2016-12-05 | 2016-12-08 | 47 |  | 40.25d |
| 49 |  | Rough-in electrical | 5d | 2016-11-25 | 2016-12-02 | 37, 36 |  | 5.75d |
| 50 |  | Conduct rough-in electrical inspection | 1d | 2016-12-02 | 2016-12-05 | 49 |  | 5.75d |
| 51 |  | Rough-in HVAC | 3d | 2016-12-05 | 2016-12-08 | 50 |  | 5.75d |
| 52 |  | Conduct rough-in HVAC inspection | 1d | 2016-12-08 | 2016-12-09 | 51 |  | 23.75d |
| 53 |  | Rough-in communication - phone, cable, computer, alarm | 2d | 2016-11-22 | 2016-11-23 | 37 |  | 16.5d |
| 54 | 8 | **Interior Finishes** | 30d | 2016-12-16 | 2017-01-27 |  |  | -0.25d |
| 55 | 8.1 | **Insulation** | 11d | 2016-12-16 | 2017-01-02 |  |  | -0.25d |
| 56 |  | Place wall insulation - 1st floor | 1d | 2016-12-16 | 2016-12-19 | 35, 41, 53, 51, 49, 36 |  | -0.25d |
| 57 |  | Place wall insulation - 2nd floor | 1d | 2016-12-19 | 2016-12-20 | 56 |  | 26.75d |
| 58 |  | Place ceiling insulation - 2nd floor | 1d | 2016-12-29 | 2016-12-30 | 64, 57 |  | 23.75d |
| 59 |  | Conduct insulation inspection | 1d | 2016-12-30 | 2017-01-02 | 58 |  | 23.75d |
| 60 | 8.2 | **Drywall** | 9d | 2016-12-19 | 2016-12-30 |  |  | -0.25d |
| 61 |  | Install drywall - 1st floor walls | 2d | 2016-12-19 | 2016-12-21 | 56 |  | -0.25d |
| 62 |  | Install drywall - 1st floor overhead | 2d | 2016-12-21 | 2016-12-23 | 61 |  | -0.25d |
| 63 |  | Install drywall 2nd floor walls | 2d | 2016-12-23 | 2016-12-27 | 62, 57 |  | 23.75d |
| 64 |  | Install drywall 2nd floor overhead | 2d | 2016-12-27 | 2016-12-29 | 63 |  | 23.75d |
| 65 |  | Tape and float 1st floor drywall | 1d | 2016-12-23 | 2016-12-26 | 62 |  | -0.25d |
| 66 |  | Tape and float 2nd floor drywall | 1d | 2016-12-29 | 2016-12-30 | 64, 65 |  | 32.25d |
| 67 | 8.3 | **Paint and Wallpaper** | 11d | 2016-12-26 | 2017-01-10 |  |  | -0.25d |
| 68 |  | Texture all except entry and kitchen - 1st floor | 1d | 2016-12-26 | 2016-12-27 | 65 |  | -0.25d |
| 69 |  | Paint all except entry and kitchen - 1st floor | 1d | 2016-12-27 | 2016-12-28 | 68 |  | -0.25d |
| 70 |  | Hang wallpaper entry and kitchen - 1st floor | 1d | 2016-12-28 | 2016-12-29 | 69 |  | -0.25d |

| ID | WBS | Task | Duration | Start | Finish | Predecessors | Total float | Constraint |
| --- | --- | --- | --- | --- | --- | --- | --- | --- |
| 71 |  | Texture all - 2nd floor | 1d | 2016-12-27 | 2016-12-28 | 68 | 33.25d |  |
| 72 |  | Paint all - 2nd floor | 1d | 2016-12-28 | 2016-12-29 | 71 | 33.25d |  |
| 73 |  | Paint exterior siding & trim work | 4d | 2017-01-04 | 2017-01-10 | 44 | 12.25d |  |
| 74 | 8.4 | **Cabinets** | 6d | 2016-12-29 | 2017-01-06 |  | -0.25d |  |
| 75 |  | Install 1st floor - kitchen cabinets | 2d | 2016-12-29 | 2017-01-02 | 70 | -0.25d |  |
| 76 |  | Install 1st floor - master bath and guest cabinets | 1d | 2017-01-02 | 2017-01-03 | 75 | -0.25d |  |
| 77 |  | Install 2nd floor - hall bath and private bath cabinets | 1d | 2017-01-03 | 2017-01-04 | 76 | 0.75d |  |
| 78 |  | Install chair rails, crown moldings, trim | 2d | 2017-01-04 | 2017-01-06 | 77 | 19.75d |  |
| 79 | 8.5 | **Finish Plumbing** | 6d | 2017-01-02 | 2017-01-10 |  | -0.25d |  |
| 80 |  | Complete 1st floor - kitchen plumbing | 1d | 2017-01-02 | 2017-01-03 | 75, 47 | -0.25d |  |
| 81 |  | Complete 1st floor - master bath and guest plumbing | 2d | 2017-01-03 | 2017-01-05 | 80, 76 | -0.25d |  |
| 82 |  | Complete 2nd floor - hall bath and private bath plumbing | 2d | 2017-01-05 | 2017-01-09 | 81, 77 | -0.25d |  |
| 83 |  | Conduct finish plumbing inspection | 1d | 2017-01-09 | 2017-01-10 | 82 | -0.25d |  |
| 84 | 8.6 | **Finish Electrical** | 3d | 2017-01-09 | 2017-01-12 |  | 0.75d |  |
| 85 |  | Complete 1st floor circuits to service panel | 1d | 2017-01-09 | 2017-01-10 | 82, 50 | 2.75d |  |
| 86 |  | Complete 2nd floor circuits to service panel | 1d | 2017-01-10 | 2017-01-11 | 85 | 2.75d |  |
| 87 |  | Conduct finish electrical inspection | 1d | 2017-01-11 | 2017-01-12 | 86 | 2.75d |  |
| 88 |  | Complete communications wiring - phone, cable, computer, alarm | 2d | 2017-01-10 | 2017-01-12 | 83 | -0.25d |  |
| 89 | 8.7 | **Finish HVAC** | 3d | 2017-01-12 | 2017-01-17 |  | -0.25d |  |
| 90 |  | Complete 1st floor - zone 1 HVAC | 1d | 2017-01-12 | 2017-01-13 | 88, 52 | -0.25d |  |
| 91 |  | Complete 2nd floor - zone 2 HVAC | 1d | 2017-01-13 | 2017-01-16 | 90 | -0.25d |  |
| 92 |  | Conduct HVAC inspection | 1d | 2017-01-16 | 2017-01-17 | 91 | -0.25d |  |
| 93 | 8.8 | **Carpet, Tile and Appliances** | 8d | 2017-01-17 | 2017-01-27 |  | -0.25d |  |
| 94 |  | Tile entry, kitchen and baths | 3d | 2017-01-17 | 2017-01-20 | 87, 92 | -0.25d |  |
| 95 |  | Carpet 1st floor | 2d | 2017-01-20 | 2017-01-24 | 94 | -0.25d |  |
| 96 |  | Carpet 2nd floor | 2d | 2017-01-24 | 2017-01-26 | 95 | -0.25d |  |
| 97 |  | Install appliances | 1d | 2017-01-26 | 2017-01-27 | 96 | -0.25d |  |
| 98 | 9 | **Landscaping and Grounds Work** | 18d | 2017-01-10 | 2017-02-03 |  | -0.25d |  |
| 99 |  | Pour concrete driveway and sidewalks | 2d | 2017-01-10 | 2017-01-11 | 73 | 12.25d |  |
| 100 |  | Install backyard fence | 2d | 2017-01-27 | 2017-01-31 | 97, 99 | -0.25d |  |
| 101 |  | Sod and complete plantings - front yard | 2d | 2017-01-31 | 2017-02-02 | 100 | -0.25d |  |
| 102 |  | Sod and complete plantings - backyard | 1d | 2017-02-02 | 2017-02-03 | 101 | -0.25d |  |
| 103 | 10 | **Final Acceptance** | 7.25d | 2017-02-03 | 2017-02-14 |  | -0.25d |  |
| 104 |  | Complete final inspection for certificate of occupancy | 6h | 2017-02-03 | 2017-02-06 | 102, 92, 87, 83, 59, 78, 48 | -0.25d |  |
| 105 |  | Cleanup for occupancy | 1d | 2017-02-06 | 2017-02-07 | 97, 104 | -0.25d |  |
| 106 |  | Perform final walk-through inspection | 1d | 2017-02-07 | 2017-02-08 | 105 | -0.25d |  |
| 107 |  | Complete punch list items | 5d | 2017-02-08 | 2017-02-14 | 106FS-2.5% | -0.25d | must finish on 2017-02-14 |

## Version 2 (saved 2017-11-28, file Organiser.mpp)

Last finish 2017-02-14 → 2018-04-12 (+422d). Complete tasks 0 → 1.

Changed:

| ID | Task | Start | Finish | Duration | Complete | Total float |
| --- | --- | --- | --- | --- | --- | --- |
| 1 | **General Conditions** | 2016-09-05 A → 2017-11-01 A (+422d) | 2016-09-26 → 2017-11-22 (+422d) | 16d → 15.25d | 33% → 51% | 0d → 101.75d |
| 2 | Complete plans and develop estimate with owner, architect | 2016-09-05 A → 2017-11-01 A (+422d) | 2016-09-23 → 2017-11-21 (+424d) |  |  | 0.25d → 102d |
| 3 | Sign contract and notice to proceed | 2016-09-26 A → 2017-11-15 A (+415d) | 2016-09-26 → 2017-11-22 A (+422d) | 1d → 5.25d | 25% → 100% | -0.75d → none |
| 4 | **Apply for Permits** | 2016-09-26 → 2017-11-22 (+422d) | 2016-09-26 → 2017-11-22 (+422d) |  |  | -0.75d → 2d |
| 5 | Secure foundaton permit | 2016-09-26 → 2017-11-22 (+422d) | 2016-09-26 → 2017-11-22 (+422d) |  |  | -0.75d → 2d |
| 6 | Secure framing permit | 2016-09-26 → 2017-11-22 (+422d) | 2016-09-26 → 2017-11-22 (+422d) |  |  | -0.75d → 2d |
| 7 | Secure electrical permit | 2016-09-26 → 2017-11-22 (+422d) | 2016-09-26 → 2017-11-22 (+422d) |  |  | -0.75d → 2d |
| 8 | Secure plumbing permit | 2016-09-26 → 2017-11-22 (+422d) | 2016-09-26 → 2017-11-22 (+422d) |  |  | -0.75d → 2d |
| 9 | Secure HVAC permit | 2016-09-26 → 2017-11-22 (+422d) | 2016-09-26 → 2017-11-22 (+422d) |  |  | -0.75d → 2d |
| 10 | Secure miscellaneous permits | 2016-09-26 → 2017-11-22 (+422d) | 2016-09-26 → 2017-11-22 (+422d) |  |  | -0.75d → 2d |
| 11 | **Site Work** | 2016-09-27 → 2017-11-22 (+421d) | 2016-09-29 → 2017-11-24 (+421d) |  |  | -0.75d → 2d |
| 12 | Clear site | 2016-09-27 → 2017-11-22 (+421d) | 2016-09-27 → 2017-11-23 (+422d) |  |  | -0.75d → 2d |
| 13 | Install temporary power service | 2016-09-28 → 2017-11-23 (+421d) | 2016-09-28 → 2017-11-23 (+421d) |  |  | -0.75d → 2d |
| 14 | Install underground utilities | 2016-09-28 → 2017-11-24 (+422d) | 2016-09-29 → 2017-11-24 (+421d) |  |  | -0.75d → 2d |
| 15 | **Foundation** | 2016-09-29 → 2017-11-27 (+424d) | 2016-10-18 → 2017-12-13 (+421d) | 13.25d → 13d |  | -0.75d → 0.75d |
| 16 | Excavate for foundations | 2016-09-29 → 2017-11-27 (+424d) | 2016-10-04 → 2017-11-29 (+421d) |  |  | -0.75d → 2d |
| 17 | Form basement walls | 2016-10-04 → 2017-11-29 (+421d) | 2016-10-08 → 2017-12-04 (+422d) |  |  | -0.75d → 2d |
| 18 | Pour concrete for foundations & basement walls | 2016-10-08 → 2017-12-04 (+422d) | 2016-10-12 → 2017-12-08 (+422d) |  |  | -1d → 1d |
| 19 | Strip basement wall forms | 2016-10-12 → 2017-12-08 (+422d) | 2016-10-13 → 2017-12-08 (+421d) |  |  | -1d → 0d |
| 20 | Waterproof/insulate basement walls | 2016-10-13 → 2017-12-08 (+421d) | 2016-10-14 → 2017-12-09 (+421d) |  |  | -0.75d → 0d |
| 21 | Perform foundation inspection | 2016-10-14 → 2017-12-11 (+423d) | 2016-10-14 → 2017-12-11 (+423d) |  |  | -0.25d → 0.75d |
| 22 | Backfill foundation | 2016-10-17 → 2017-12-12 (+421d) | 2016-10-18 → 2017-12-13 (+421d) |  |  | -0.25d → 0.75d |
| 23 | **Framing** | 2016-10-19 → 2017-12-14 (+421d) | 2016-11-17 → 2018-01-12 (+421d) |  |  | -0.25d → 0.75d |
| 24 | Install 1st floor joists | 2016-10-19 → 2017-12-14 (+421d) | 2016-10-20 → 2017-12-15 (+421d) |  |  | -0.25d → 0.75d |
| 25 | Lay 1st floor decking | 2016-10-21 → 2017-12-18 (+423d) | 2016-10-24 → 2017-12-19 (+421d) |  |  | -0.25d → 0.75d |
| 26 | Frame 1st floor walls | 2016-10-25 → 2017-12-20 (+421d) | 2016-10-28 → 2017-12-25 (+423d) |  |  | -0.25d → 0.75d |
| 27 | Frame 1st floor corners | 2016-10-31 → 2017-12-26 (+421d) | 2016-10-31 → 2017-12-26 (+421d) |  |  | -0.25d → 0.75d |
| 28 | Install 2nd floor joists | 2016-11-01 → 2017-12-27 (+421d) | 2016-11-02 → 2017-12-28 (+421d) |  |  | -0.25d → 0.75d |
| 29 | Frame 2nd floor decking | 2016-11-03 → 2017-12-29 (+421d) | 2016-11-04 → 2018-01-01 (+423d) |  |  | -0.25d → 0.75d |
| 30 | Frame 2nd floor walls | 2016-11-07 → 2018-01-02 (+421d) | 2016-11-09 → 2018-01-04 (+421d) |  |  | -0.25d → 0.75d |
| 31 | Frame 2nd floor corners | 2016-11-10 → 2018-01-05 (+421d) | 2016-11-11 → 2018-01-08 (+423d) |  |  | -0.25d → 0.75d |
| 32 | Complete roof framing | 2016-11-14 → 2018-01-09 (+421d) | 2016-11-16 → 2018-01-11 (+421d) |  |  | -0.25d → 0.75d |
| 33 | Conduct framing inspection | 2016-11-17 → 2018-01-12 (+421d) | 2016-11-17 → 2018-01-12 (+421d) |  |  | -0.25d → 0.75d |
| 34 | **Dry In** | 2016-11-17 → 2018-01-12 (+421d) | 2016-12-16 → 2018-02-12 (+423d) |  |  | -0.25d → 0.75d |
| 35 | Install 1st floor sheathing | 2016-11-17 → 2018-01-12 (+421d) | 2016-11-22 → 2018-01-17 (+421d) |  |  | -0.25d → 0.75d |
| 36 | Install 2nd floor sheathing | 2016-11-22 → 2018-01-17 (+421d) | 2016-11-25 → 2018-01-22 (+423d) |  |  | -0.25d → 0.75d |
| 37 | Install roof decking | 2016-11-17 → 2018-01-12 (+421d) | 2016-11-21 → 2018-01-16 (+421d) |  |  | 3.5d → 4.5d |
| 38 | Install felt, flashing and shingles | 2016-12-02 → 2018-01-29 (+423d) | 2016-12-07 → 2018-02-01 (+421d) |  |  | -0.25d → 0.75d |
| 39 | Hang 1st floor exterior doors | 2016-12-07 → 2018-02-01 (+421d) | 2016-12-08 → 2018-02-02 (+421d) |  |  | -0.25d → 0.75d |
| 40 | Install 1st floor windows | 2016-12-08 → 2018-02-02 (+421d) | 2016-12-13 → 2018-02-07 (+421d) |  |  | -0.25d → 0.75d |
| 41 | Install 2nd floor windows | 2016-12-13 → 2018-02-07 (+421d) | 2016-12-16 → 2018-02-12 (+423d) |  |  | -0.25d → 0.75d |
| 42 | **Exterior Finishes** | 2016-12-16 → 2018-02-12 (+423d) | 2017-01-04 → 2018-03-01 (+421d) |  |  | 12.25d → 13.25d |
| 43 | Complete exterior brick | 2016-12-16 → 2018-02-12 (+423d) | 2016-12-30 → 2018-02-26 (+423d) |  |  | 12.25d → 13.25d |
| 44 | Complete exterior siding | 2016-12-30 → 2018-02-26 (+423d) | 2017-01-04 → 2018-03-01 (+421d) |  |  | 12.25d → 13.25d |
| 45 | **Utility Rough-Ins and Complete Concrete** | 2016-11-22 → 2018-01-17 (+421d) | 2016-12-09 → 2018-02-05 (+423d) |  |  | 3.5d → 4.5d |
| 46 | Rough-in plumbing | 2016-11-25 → 2018-01-22 (+423d) | 2016-12-02 → 2018-01-29 (+423d) |  |  | -0.25d → 0.75d |
| 47 | Conduct rough-in plumbing inspection | 2016-12-02 → 2018-01-29 (+423d) | 2016-12-05 → 2018-01-30 (+421d) |  |  | 19.75d → 20.75d |
| 48 | Place concrete for basement floor | 2016-12-05 → 2018-01-30 (+421d) | 2016-12-08 → 2018-02-02 (+421d) |  |  | 40.25d → 41.5d |
| 49 | Rough-in electrical | 2016-11-25 → 2018-01-22 (+423d) | 2016-12-02 → 2018-01-29 (+423d) |  |  | 5.75d → 6.75d |
| 50 | Conduct rough-in electrical inspection | 2016-12-02 → 2018-01-29 (+423d) | 2016-12-05 → 2018-01-30 (+421d) |  |  | 5.75d → 6.75d |
| 51 | Rough-in HVAC | 2016-12-05 → 2018-01-30 (+421d) | 2016-12-08 → 2018-02-02 (+421d) |  |  | 5.75d → 6.75d |
| 52 | Conduct rough-in HVAC inspection | 2016-12-08 → 2018-02-02 (+421d) | 2016-12-09 → 2018-02-05 (+423d) |  |  | 23.75d → 24.75d |
| 53 | Rough-in communication - phone, cable, computer, alarm | 2016-11-22 → 2018-01-17 (+421d) | 2016-11-23 → 2018-01-18 (+421d) |  |  | 16.5d → 17.5d |
| 54 | **Interior Finishes** | 2016-12-16 → 2018-02-12 (+423d) | 2017-01-27 → 2018-03-26 (+423d) |  |  | -0.25d → 0.75d |
| 55 | **Insulation** | 2016-12-16 → 2018-02-12 (+423d) | 2017-01-02 → 2018-02-27 (+421d) |  |  | -0.25d → 0.75d |
| 56 | Place wall insulation - 1st floor | 2016-12-16 → 2018-02-12 (+423d) | 2016-12-19 → 2018-02-13 (+421d) |  |  | -0.25d → 0.75d |
| 57 | Place wall insulation - 2nd floor | 2016-12-19 → 2018-02-13 (+421d) | 2016-12-20 → 2018-02-14 (+421d) |  |  | 26.75d → 27.75d |
| 58 | Place ceiling insulation - 2nd floor | 2016-12-29 → 2018-02-23 (+421d) | 2016-12-30 → 2018-02-26 (+423d) |  |  | 23.75d → 24.75d |
| 59 | Conduct insulation inspection | 2016-12-30 → 2018-02-26 (+423d) | 2017-01-02 → 2018-02-27 (+421d) |  |  | 23.75d → 24.75d |
| 60 | **Drywall** | 2016-12-19 → 2018-02-13 (+421d) | 2016-12-30 → 2018-02-26 (+423d) |  |  | -0.25d → 0.75d |
| 61 | Install drywall - 1st floor walls | 2016-12-19 → 2018-02-13 (+421d) | 2016-12-21 → 2018-02-15 (+421d) |  |  | -0.25d → 0.75d |
| 62 | Install drywall - 1st floor overhead | 2016-12-21 → 2018-02-15 (+421d) | 2016-12-23 → 2018-02-19 (+423d) |  |  | -0.25d → 0.75d |
| 63 | Install drywall 2nd floor walls | 2016-12-23 → 2018-02-19 (+423d) | 2016-12-27 → 2018-02-21 (+421d) |  |  | 23.75d → 24.75d |
| 64 | Install drywall 2nd floor overhead | 2016-12-27 → 2018-02-21 (+421d) | 2016-12-29 → 2018-02-23 (+421d) |  |  | 23.75d → 24.75d |
| 65 | Tape and float 1st floor drywall | 2016-12-23 → 2018-02-19 (+423d) | 2016-12-26 → 2018-02-20 (+421d) |  |  | -0.25d → 0.75d |
| 66 | Tape and float 2nd floor drywall | 2016-12-29 → 2018-02-23 (+421d) | 2016-12-30 → 2018-02-26 (+423d) |  |  | 32.25d → 33.25d |
| 67 | **Paint and Wallpaper** | 2016-12-26 → 2018-02-20 (+421d) | 2017-01-10 → 2018-03-07 (+421d) |  |  | -0.25d → 0.75d |
| 68 | Texture all except entry and kitchen - 1st floor | 2016-12-26 → 2018-02-20 (+421d) | 2016-12-27 → 2018-02-21 (+421d) |  |  | -0.25d → 0.75d |
| 69 | Paint all except entry and kitchen - 1st floor | 2016-12-27 → 2018-02-21 (+421d) | 2016-12-28 → 2018-02-22 (+421d) |  |  | -0.25d → 0.75d |
| 70 | Hang wallpaper entry and kitchen - 1st floor | 2016-12-28 → 2018-02-22 (+421d) | 2016-12-29 → 2018-02-23 (+421d) |  |  | -0.25d → 0.75d |

| ID | Task | Start | Finish | Duration | Total float | Other |
| --- | --- | --- | --- | --- | --- | --- |
| 71 | Texture all - 2nd floor | 2016-12-27 → 2018-02-21 (+421d) | 2016-12-28 → 2018-02-22 (+421d) |  | 33.25d → 34.25d |  |
| 72 | Paint all - 2nd floor | 2016-12-28 → 2018-02-22 (+421d) | 2016-12-29 → 2018-02-23 (+421d) |  | 33.25d → 34.25d |  |
| 73 | Paint exterior siding & trim work | 2017-01-04 → 2018-03-01 (+421d) | 2017-01-10 → 2018-03-07 (+421d) |  | 12.25d → 13.25d |  |
| 74 | **Cabinets** | 2016-12-29 → 2018-02-23 (+421d) | 2017-01-06 → 2018-03-05 (+423d) |  | -0.25d → 0.75d |  |
| 75 | Install 1st floor - kitchen cabinets | 2016-12-29 → 2018-02-23 (+421d) | 2017-01-02 → 2018-02-27 (+421d) |  | -0.25d → 0.75d |  |
| 76 | Install 1st floor - master bath and guest cabinets | 2017-01-02 → 2018-02-27 (+421d) | 2017-01-03 → 2018-02-28 (+421d) |  | -0.25d → 0.75d |  |
| 77 | Install 2nd floor - hall bath and private bath cabinets | 2017-01-03 → 2018-02-28 (+421d) | 2017-01-04 → 2018-03-01 (+421d) |  | 0.75d → 1.75d |  |
| 78 | Install chair rails, crown moldings, trim | 2017-01-04 → 2018-03-01 (+421d) | 2017-01-06 → 2018-03-05 (+423d) |  | 19.75d → 20.75d |  |
| 79 | **Finish Plumbing** | 2017-01-02 → 2018-02-27 (+421d) | 2017-01-10 → 2018-03-07 (+421d) |  | -0.25d → 0.75d |  |
| 80 | Complete 1st floor - kitchen plumbing | 2017-01-02 → 2018-02-27 (+421d) | 2017-01-03 → 2018-02-28 (+421d) |  | -0.25d → 0.75d |  |
| 81 | Complete 1st floor - master bath and guest plumbing | 2017-01-03 → 2018-02-28 (+421d) | 2017-01-05 → 2018-03-02 (+421d) |  | -0.25d → 0.75d |  |
| 82 | Complete 2nd floor - hall bath and private bath plumbing | 2017-01-05 → 2018-03-02 (+421d) | 2017-01-09 → 2018-03-06 (+421d) |  | -0.25d → 0.75d |  |
| 83 | Conduct finish plumbing inspection | 2017-01-09 → 2018-03-06 (+421d) | 2017-01-10 → 2018-03-07 (+421d) |  | -0.25d → 0.75d |  |
| 84 | **Finish Electrical** | 2017-01-09 → 2018-03-06 (+421d) | 2017-01-12 → 2018-03-09 (+421d) |  | 0.75d → 1.75d |  |
| 85 | Complete 1st floor circuits to service panel | 2017-01-09 → 2018-03-06 (+421d) | 2017-01-10 → 2018-03-07 (+421d) |  | 2.75d → 3.75d |  |
| 86 | Complete 2nd floor circuits to service panel | 2017-01-10 → 2018-03-07 (+421d) | 2017-01-11 → 2018-03-08 (+421d) |  | 2.75d → 3.75d |  |
| 87 | Conduct finish electrical inspection | 2017-01-11 → 2018-03-08 (+421d) | 2017-01-12 → 2018-03-09 (+421d) |  | 2.75d → 3.75d |  |
| 88 | Complete communications wiring - phone, cable, computer, alarm | 2017-01-10 → 2018-03-07 (+421d) | 2017-01-12 → 2018-03-09 (+421d) |  | -0.25d → 0.75d |  |
| 89 | **Finish HVAC** | 2017-01-12 → 2018-03-09 (+421d) | 2017-01-17 → 2018-03-14 (+421d) |  | -0.25d → 0.75d |  |
| 90 | Complete 1st floor - zone 1 HVAC | 2017-01-12 → 2018-03-09 (+421d) | 2017-01-13 → 2018-03-12 (+423d) |  | -0.25d → 0.75d |  |
| 91 | Complete 2nd floor - zone 2 HVAC | 2017-01-13 → 2018-03-12 (+423d) | 2017-01-16 → 2018-03-13 (+421d) |  | -0.25d → 0.75d |  |
| 92 | Conduct HVAC inspection | 2017-01-16 → 2018-03-13 (+421d) | 2017-01-17 → 2018-03-14 (+421d) |  | -0.25d → 0.75d |  |
| 93 | **Carpet, Tile and Appliances** | 2017-01-17 → 2018-03-14 (+421d) | 2017-01-27 → 2018-03-26 (+423d) |  | -0.25d → 0.75d |  |
| 94 | Tile entry, kitchen and baths | 2017-01-17 → 2018-03-14 (+421d) | 2017-01-20 → 2018-03-19 (+423d) |  | -0.25d → 0.75d |  |
| 95 | Carpet 1st floor | 2017-01-20 → 2018-03-19 (+423d) | 2017-01-24 → 2018-03-21 (+421d) |  | -0.25d → 0.75d |  |
| 96 | Carpet 2nd floor | 2017-01-24 → 2018-03-21 (+421d) | 2017-01-26 → 2018-03-23 (+421d) |  | -0.25d → 0.75d |  |
| 97 | Install appliances | 2017-01-26 → 2018-03-23 (+421d) | 2017-01-27 → 2018-03-26 (+423d) |  | -0.25d → 0.75d |  |
| 98 | **Landscaping and Grounds Work** | 2017-01-10 → 2018-03-07 (+421d) | 2017-02-03 → 2018-04-02 (+423d) |  | -0.25d → 0.75d |  |
| 99 | Pour concrete driveway and sidewalks | 2017-01-10 → 2018-03-07 (+421d) | 2017-01-11 → 2018-03-08 (+421d) |  | 12.25d → 13.25d |  |
| 100 | Install backyard fence | 2017-01-27 → 2018-03-26 (+423d) | 2017-01-31 → 2018-03-28 (+421d) |  | -0.25d → 0.75d |  |
| 101 | Sod and complete plantings - front yard | 2017-01-31 → 2018-03-28 (+421d) | 2017-02-02 → 2018-03-30 (+421d) |  | -0.25d → 0.75d |  |
| 102 | Sod and complete plantings - backyard | 2017-02-02 → 2018-03-30 (+421d) | 2017-02-03 → 2018-04-02 (+423d) |  | -0.25d → 0.75d |  |
| 103 | **Final Acceptance** | 2017-02-03 → 2018-04-02 (+423d) | 2017-02-14 → 2018-04-12 (+422d) | 7.25d → 8.25d | -0.25d → 0d |  |
| 104 | Complete final inspection for certificate of occupancy | 2017-02-03 → 2018-04-02 (+423d) | 2017-02-06 → 2018-04-03 (+421d) |  | -0.25d → 0.75d |  |
| 105 | Cleanup for occupancy | 2017-02-06 → 2018-04-03 (+421d) | 2017-02-07 → 2018-04-04 (+421d) |  | -0.25d → 0.75d |  |
| 106 | Perform final walk-through inspection | 2017-02-07 → 2018-04-04 (+421d) | 2017-02-08 → 2018-04-05 (+421d) |  | -0.25d → 0.75d |  |
| 107 | Complete punch list items | 2017-02-08 → 2018-04-06 (+422d) | 2017-02-14 → 2018-04-12 (+422d) |  | -0.25d → 0d | constraint must finish on 2017-02-14 → must finish on 2018-04-12 |

## Version 3 (saved 2019-03-11, file Costs.mpp)

Last finish 2018-04-12 → 2019-08-13 (+488d). Complete tasks 1 → 0.

Changed:

| ID | Task | Start | Finish | Duration | Complete | Total float | Other |
| --- | --- | --- | --- | --- | --- | --- | --- |
| 1 | **General Conditions** | 2017-11-01 A → 2019-03-01 (+485d) | 2017-11-22 → 2019-03-22 (+485d) | 15.25d → 16d | 51% → 0% | 101.75d → 0d | baseline start 2016-09-05 → none; baseline finish 2016-09-26 → none |
| 2 | Complete plans and develop estimate with owner, architect | 2017-11-01 A → 2019-03-01 (+485d) | 2017-11-21 → 2019-03-21 (+485d) |  | 33% → 0% | 102d → 0d | baseline start 2016-09-05 → none; baseline finish 2016-09-23 → none |
| 3 | Sign contract and notice to proceed | 2017-11-15 A → 2019-03-22 (+492d) | 2017-11-22 A → 2019-03-22 (+485d) | 5.25d → 1d | 100% → 0% | none → 0d | baseline start 2016-09-26 → none; baseline finish 2016-09-26 → none |
| 4 | **Apply for Permits** | 2017-11-22 → 2019-03-22 (+485d) | 2017-11-22 → 2019-03-22 (+485d) |  |  | 2d → 0.12d | baseline start 2016-09-26 → none; baseline finish 2016-09-26 → none |
| 5 | Secure foundaton permit | 2017-11-22 → 2019-03-22 (+485d) | 2017-11-22 → 2019-03-22 (+485d) |  |  | 2d → 0.12d | resources General contractor; Permit → General contractor; baseline start 2016-09-26 → none; baseline finish 2016-09-26 → none |
| 6 | Secure framing permit | 2017-11-22 → 2019-03-22 (+485d) | 2017-11-22 → 2019-03-22 (+485d) |  |  | 2d → 0.12d | resources General contractor; Permit → General contractor; baseline start 2016-09-26 → none; baseline finish 2016-09-26 → none |
| 7 | Secure electrical permit | 2017-11-22 → 2019-03-22 (+485d) | 2017-11-22 → 2019-03-22 (+485d) |  |  | 2d → 0.12d | resources General contractor; Permit → General contractor; baseline start 2016-09-26 → none; baseline finish 2016-09-26 → none |
| 8 | Secure plumbing permit | 2017-11-22 → 2019-03-22 (+485d) | 2017-11-22 → 2019-03-22 (+485d) |  |  | 2d → 0.12d | resources General contractor; Permit → General contractor; baseline start 2016-09-26 → none; baseline finish 2016-09-26 → none |
| 9 | Secure HVAC permit | 2017-11-22 → 2019-03-22 (+485d) | 2017-11-22 → 2019-03-22 (+485d) |  |  | 2d → 0.12d | resources General contractor; Permit → General contractor; baseline start 2016-09-26 → none; baseline finish 2016-09-26 → none |
| 10 | Secure miscellaneous permits | 2017-11-22 → 2019-03-22 (+485d) | 2017-11-22 → 2019-03-22 (+485d) |  |  | 2d → 0.12d | resources General contractor; Permit → General contractor; baseline start 2016-09-26 → none; baseline finish 2016-09-26 → none |
| 11 | **Site Work** | 2017-11-22 → 2019-03-25 (+488d) | 2017-11-24 → 2019-03-27 (+488d) |  |  | 2d → 0.12d | baseline start 2016-09-27 → none; baseline finish 2016-09-29 → none |
| 12 | Clear site | 2017-11-22 → 2019-03-25 (+488d) | 2017-11-23 → 2019-03-25 (+487d) |  |  | 2d → 0.12d | baseline start 2016-09-27 → none; baseline finish 2016-09-27 → none |
| 13 | Install temporary power service | 2017-11-23 → 2019-03-26 (+488d) | 2017-11-23 → 2019-03-26 (+488d) |  |  | 2d → 0.12d | baseline start 2016-09-28 → none; baseline finish 2016-09-28 → none |
| 14 | Install underground utilities | 2017-11-24 → 2019-03-26 (+487d) | 2017-11-24 → 2019-03-27 (+488d) |  |  | 2d → 0.12d | baseline start 2016-09-28 → none; baseline finish 2016-09-29 → none |
| 15 | **Foundation** | 2017-11-27 → 2019-03-27 (+485d) | 2017-12-13 → 2019-04-15 (+488d) | 13d → 13.25d |  | 0.75d → 0d | baseline start 2016-09-29 → none; baseline finish 2016-10-18 → none |
| 16 | Excavate for foundations | 2017-11-27 → 2019-03-27 (+485d) | 2017-11-29 → 2019-04-01 (+488d) |  |  | 2d → 0.12d | baseline start 2016-09-29 → none; baseline finish 2016-10-04 → none |
| 17 | Form basement walls | 2017-11-29 → 2019-04-01 (+488d) | 2017-12-04 → 2019-04-05 (+487d) |  |  | 2d → 0d | baseline start 2016-10-04 → none; baseline finish 2016-10-08 → none |
| 18 | Pour concrete for foundations & basement walls | 2017-12-04 → 2019-04-05 (+487d) | 2017-12-08 → 2019-04-09 (+487d) |  |  | 1d → 0d | baseline start 2016-10-08 → none; baseline finish 2016-10-12 → none |
| 19 | Strip basement wall forms | 2017-12-08 → 2019-04-09 (+487d) | 2017-12-08 → 2019-04-10 (+488d) |  |  |  | baseline start 2016-10-12 → none; baseline finish 2016-10-13 → none |
| 20 | Waterproof/insulate basement walls | 2017-12-08 → 2019-04-10 (+488d) | 2017-12-09 → 2019-04-11 (+488d) |  |  |  | baseline start 2016-10-13 → none; baseline finish 2016-10-14 → none |
| 21 | Perform foundation inspection | 2017-12-11 → 2019-04-11 (+486d) | 2017-12-11 → 2019-04-11 (+486d) |  |  | 0.75d → 0d | baseline start 2016-10-14 → none; baseline finish 2016-10-14 → none |
| 22 | Backfill foundation | 2017-12-12 → 2019-04-12 (+486d) | 2017-12-13 → 2019-04-15 (+488d) |  |  | 0.75d → 0d | baseline start 2016-10-17 → none; baseline finish 2016-10-18 → none |
| 23 | **Framing** | 2017-12-14 → 2019-04-16 (+488d) | 2018-01-12 → 2019-05-15 (+488d) |  |  | 0.75d → 0d | baseline start 2016-10-19 → none; baseline finish 2016-11-17 → none |
| 24 | Install 1st floor joists | 2017-12-14 → 2019-04-16 (+488d) | 2017-12-15 → 2019-04-17 (+488d) |  |  | 0.75d → 0d | baseline start 2016-10-19 → none; baseline finish 2016-10-20 → none |
| 25 | Lay 1st floor decking | 2017-12-18 → 2019-04-18 (+486d) | 2017-12-19 → 2019-04-19 (+486d) |  |  | 0.75d → 0d | baseline start 2016-10-21 → none; baseline finish 2016-10-24 → none |
| 26 | Frame 1st floor walls | 2017-12-20 → 2019-04-22 (+488d) | 2017-12-25 → 2019-04-25 (+486d) |  |  | 0.75d → 0d | baseline start 2016-10-25 → none; baseline finish 2016-10-28 → none |
| 27 | Frame 1st floor corners | 2017-12-26 → 2019-04-26 (+486d) | 2017-12-26 → 2019-04-26 (+486d) |  |  | 0.75d → 0d | baseline start 2016-10-31 → none; baseline finish 2016-10-31 → none |
| 28 | Install 2nd floor joists | 2017-12-27 → 2019-04-29 (+488d) | 2017-12-28 → 2019-04-30 (+488d) |  |  | 0.75d → 0d | baseline start 2016-11-01 → none; baseline finish 2016-11-02 → none |
| 29 | Frame 2nd floor decking | 2017-12-29 → 2019-05-01 (+488d) | 2018-01-01 → 2019-05-02 (+486d) |  |  | 0.75d → 0d | baseline start 2016-11-03 → none; baseline finish 2016-11-04 → none |
| 30 | Frame 2nd floor walls | 2018-01-02 → 2019-05-03 (+486d) | 2018-01-04 → 2019-05-07 (+488d) |  |  | 0.75d → 0d | baseline start 2016-11-07 → none; baseline finish 2016-11-09 → none |
| 31 | Frame 2nd floor corners | 2018-01-05 → 2019-05-08 (+488d) | 2018-01-08 → 2019-05-09 (+486d) |  |  | 0.75d → 0d | baseline start 2016-11-10 → none; baseline finish 2016-11-11 → none |
| 32 | Complete roof framing | 2018-01-09 → 2019-05-10 (+486d) | 2018-01-11 → 2019-05-14 (+488d) |  |  | 0.75d → 0d | baseline start 2016-11-14 → none; baseline finish 2016-11-16 → none |
| 33 | Conduct framing inspection | 2018-01-12 → 2019-05-15 (+488d) | 2018-01-12 → 2019-05-15 (+488d) |  |  | 0.75d → 0d | baseline start 2016-11-17 → none; baseline finish 2016-11-17 → none |
| 34 | **Dry In** | 2018-01-12 → 2019-05-15 (+488d) | 2018-02-12 → 2019-06-13 (+486d) |  |  | 0.75d → 0d | baseline start 2016-11-17 → none; baseline finish 2016-12-16 → none |
| 35 | Install 1st floor sheathing | 2018-01-12 → 2019-05-15 (+488d) | 2018-01-17 → 2019-05-20 (+488d) |  |  | 0.75d → 0d | baseline start 2016-11-17 → none; baseline finish 2016-11-22 → none |
| 36 | Install 2nd floor sheathing | 2018-01-17 → 2019-05-20 (+488d) | 2018-01-22 → 2019-05-23 (+486d) |  |  | 0.75d → 0d | baseline start 2016-11-22 → none; baseline finish 2016-11-25 → none |
| 37 | Install roof decking | 2018-01-12 → 2019-05-15 (+488d) | 2018-01-16 → 2019-05-17 (+486d) |  |  | 4.5d → 3.75d | baseline start 2016-11-17 → none; baseline finish 2016-11-21 → none |
| 38 | Install felt, flashing and shingles | 2018-01-29 → 2019-05-30 (+486d) | 2018-02-01 → 2019-06-04 (+488d) |  |  | 0.75d → 0d | baseline start 2016-12-02 → none; baseline finish 2016-12-07 → none |
| 39 | Hang 1st floor exterior doors | 2018-02-01 → 2019-06-04 (+488d) | 2018-02-02 → 2019-06-05 (+488d) |  |  | 0.75d → 0d | baseline start 2016-12-07 → none; baseline finish 2016-12-08 → none |
| 40 | Install 1st floor windows | 2018-02-02 → 2019-06-05 (+488d) | 2018-02-07 → 2019-06-10 (+488d) |  |  | 0.75d → 0d | baseline start 2016-12-08 → none; baseline finish 2016-12-13 → none |
| 41 | Install 2nd floor windows | 2018-02-07 → 2019-06-10 (+488d) | 2018-02-12 → 2019-06-13 (+486d) |  |  | 0.75d → 0d | baseline start 2016-12-13 → none; baseline finish 2016-12-16 → none |
| 42 | **Exterior Finishes** | 2018-02-12 → 2019-06-13 (+486d) | 2018-03-01 → 2019-07-02 (+488d) |  |  | 13.25d → 12.25d | baseline start 2016-12-16 → none; baseline finish 2017-01-04 → none |
| 43 | Complete exterior brick | 2018-02-12 → 2019-06-13 (+486d) | 2018-02-26 → 2019-06-27 (+486d) |  |  | 13.25d → 12.25d | baseline start 2016-12-16 → none; baseline finish 2016-12-30 → none |
| 44 | Complete exterior siding | 2018-02-26 → 2019-06-27 (+486d) | 2018-03-01 → 2019-07-02 (+488d) |  |  | 13.25d → 12.25d | baseline start 2016-12-30 → none; baseline finish 2017-01-04 → none |
| 45 | **Utility Rough-Ins and Complete Concrete** | 2018-01-17 → 2019-05-20 (+488d) | 2018-02-05 → 2019-06-06 (+486d) |  |  | 4.5d → 3.75d | baseline start 2016-11-22 → none; baseline finish 2016-12-09 → none |
| 46 | Rough-in plumbing | 2018-01-22 → 2019-05-23 (+486d) | 2018-01-29 → 2019-05-30 (+486d) |  |  | 0.75d → 0d | baseline start 2016-11-25 → none; baseline finish 2016-12-02 → none |
| 47 | Conduct rough-in plumbing inspection | 2018-01-29 → 2019-05-30 (+486d) | 2018-01-30 → 2019-05-31 (+486d) |  |  | 20.75d → 20d | baseline start 2016-12-02 → none; baseline finish 2016-12-05 → none |
| 48 | Place concrete for basement floor | 2018-01-30 → 2019-05-31 (+486d) | 2018-02-02 → 2019-06-03 (+486d) |  |  | 41.5d → 40.25d | baseline start 2016-12-05 → none; baseline finish 2016-12-08 → none |
| 49 | Rough-in electrical | 2018-01-22 → 2019-05-23 (+486d) | 2018-01-29 → 2019-05-30 (+486d) |  |  | 6.75d → 6d | baseline start 2016-11-25 → none; baseline finish 2016-12-02 → none |
| 50 | Conduct rough-in electrical inspection | 2018-01-29 → 2019-05-30 (+486d) | 2018-01-30 → 2019-05-31 (+486d) |  |  | 6.75d → 6d | baseline start 2016-12-02 → none; baseline finish 2016-12-05 → none |
| 51 | Rough-in HVAC | 2018-01-30 → 2019-05-31 (+486d) | 2018-02-02 → 2019-06-05 (+488d) |  |  | 6.75d → 6d | baseline start 2016-12-05 → none; baseline finish 2016-12-08 → none |
| 52 | Conduct rough-in HVAC inspection | 2018-02-02 → 2019-06-05 (+488d) | 2018-02-05 → 2019-06-06 (+486d) |  |  | 24.75d → 24d | baseline start 2016-12-08 → none; baseline finish 2016-12-09 → none |
| 53 | Rough-in communication - phone, cable, computer, alarm | 2018-01-17 → 2019-05-20 (+488d) | 2018-01-18 → 2019-05-21 (+488d) |  |  | 17.5d → 16.75d | baseline start 2016-11-22 → none; baseline finish 2016-11-23 → none |
| 54 | **Interior Finishes** | 2018-02-12 → 2019-06-13 (+486d) | 2018-03-26 → 2019-07-25 (+486d) |  |  | 0.75d → 0d | baseline start 2016-12-16 → none; baseline finish 2017-01-27 → none |
| 55 | **Insulation** | 2018-02-12 → 2019-06-13 (+486d) | 2018-02-27 → 2019-06-28 (+486d) |  |  | 0.75d → 0d | baseline start 2016-12-16 → none; baseline finish 2017-01-02 → none |
| 56 | Place wall insulation - 1st floor | 2018-02-12 → 2019-06-13 (+486d) | 2018-02-13 → 2019-06-14 (+486d) |  |  | 0.75d → 0d | baseline start 2016-12-16 → none; baseline finish 2016-12-19 → none |
| 57 | Place wall insulation - 2nd floor | 2018-02-13 → 2019-06-14 (+486d) | 2018-02-14 → 2019-06-17 (+488d) |  |  | 27.75d → 27d | baseline start 2016-12-19 → none; baseline finish 2016-12-20 → none |
| 58 | Place ceiling insulation - 2nd floor | 2018-02-23 → 2019-06-26 (+488d) | 2018-02-26 → 2019-06-27 (+486d) |  |  | 24.75d → 24d | baseline start 2016-12-29 → none; baseline finish 2016-12-30 → none |
| 59 | Conduct insulation inspection | 2018-02-26 → 2019-06-27 (+486d) | 2018-02-27 → 2019-06-28 (+486d) |  |  | 24.75d → 24d | baseline start 2016-12-30 → none; baseline finish 2017-01-02 → none |
| 60 | **Drywall** | 2018-02-13 → 2019-06-14 (+486d) | 2018-02-26 → 2019-06-27 (+486d) |  |  | 0.75d → 0d | baseline start 2016-12-19 → none; baseline finish 2016-12-30 → none |
| 61 | Install drywall - 1st floor walls | 2018-02-13 → 2019-06-14 (+486d) | 2018-02-15 → 2019-06-18 (+488d) |  |  | 0.75d → 0d | baseline start 2016-12-19 → none; baseline finish 2016-12-21 → none |
| 62 | Install drywall - 1st floor overhead | 2018-02-15 → 2019-06-18 (+488d) | 2018-02-19 → 2019-06-20 (+486d) |  |  | 0.75d → 0d | baseline start 2016-12-21 → none; baseline finish 2016-12-23 → none |
| 63 | Install drywall 2nd floor walls | 2018-02-19 → 2019-06-20 (+486d) | 2018-02-21 → 2019-06-24 (+488d) |  |  | 24.75d → 24d | baseline start 2016-12-23 → none; baseline finish 2016-12-27 → none |
| 64 | Install drywall 2nd floor overhead | 2018-02-21 → 2019-06-24 (+488d) | 2018-02-23 → 2019-06-26 (+488d) |  |  | 24.75d → 24d | baseline start 2016-12-27 → none; baseline finish 2016-12-29 → none |
| 65 | Tape and float 1st floor drywall | 2018-02-19 → 2019-06-20 (+486d) | 2018-02-20 → 2019-06-21 (+486d) |  |  | 0.75d → 0d | baseline start 2016-12-23 → none; baseline finish 2016-12-26 → none |
| 66 | Tape and float 2nd floor drywall | 2018-02-23 → 2019-06-26 (+488d) | 2018-02-26 → 2019-06-27 (+486d) |  |  | 33.25d → 32.5d | baseline start 2016-12-29 → none; baseline finish 2016-12-30 → none |
| 67 | **Paint and Wallpaper** | 2018-02-20 → 2019-06-21 (+486d) | 2018-03-07 → 2019-07-08 (+488d) |  |  | 0.75d → 0d | baseline start 2016-12-26 → none; baseline finish 2017-01-10 → none |
| 68 | Texture all except entry and kitchen - 1st floor | 2018-02-20 → 2019-06-21 (+486d) | 2018-02-21 → 2019-06-24 (+488d) |  |  | 0.75d → 0d | baseline start 2016-12-26 → none; baseline finish 2016-12-27 → none |
| 69 | Paint all except entry and kitchen - 1st floor | 2018-02-21 → 2019-06-24 (+488d) | 2018-02-22 → 2019-06-25 (+488d) |  |  | 0.75d → 0d | baseline start 2016-12-27 → none; baseline finish 2016-12-28 → none |
| 70 | Hang wallpaper entry and kitchen - 1st floor | 2018-02-22 → 2019-06-25 (+488d) | 2018-02-23 → 2019-06-26 (+488d) |  |  | 0.75d → 0d | baseline start 2016-12-28 → none; baseline finish 2016-12-29 → none |

| ID | Task | Start | Finish | Duration | Total float | Other |
| --- | --- | --- | --- | --- | --- | --- |
| 71 | Texture all - 2nd floor | 2018-02-21 → 2019-06-24 (+488d) | 2018-02-22 → 2019-06-25 (+488d) |  | 34.25d → 33.5d | baseline start 2016-12-27 → none; baseline finish 2016-12-28 → none |
| 72 | Paint all - 2nd floor | 2018-02-22 → 2019-06-25 (+488d) | 2018-02-23 → 2019-06-26 (+488d) |  | 34.25d → 33.5d | baseline start 2016-12-28 → none; baseline finish 2016-12-29 → none |
| 73 | Paint exterior siding & trim work | 2018-03-01 → 2019-07-02 (+488d) | 2018-03-07 → 2019-07-08 (+488d) |  | 13.25d → 12.25d | baseline start 2017-01-04 → none; baseline finish 2017-01-10 → none |
| 74 | **Cabinets** | 2018-02-23 → 2019-06-26 (+488d) | 2018-03-05 → 2019-07-04 (+486d) |  | 0.75d → 0d | baseline start 2016-12-29 → none; baseline finish 2017-01-06 → none |
| 75 | Install 1st floor - kitchen cabinets | 2018-02-23 → 2019-06-26 (+488d) | 2018-02-27 → 2019-06-28 (+486d) |  | 0.75d → 0d | baseline start 2016-12-29 → none; baseline finish 2017-01-02 → none |
| 76 | Install 1st floor - master bath and guest cabinets | 2018-02-27 → 2019-06-28 (+486d) | 2018-02-28 → 2019-07-01 (+488d) |  | 0.75d → 0d | baseline start 2017-01-02 → none; baseline finish 2017-01-03 → none |
| 77 | Install 2nd floor - hall bath and private bath cabinets | 2018-02-28 → 2019-07-01 (+488d) | 2018-03-01 → 2019-07-02 (+488d) |  | 1.75d → 1d | baseline start 2017-01-03 → none; baseline finish 2017-01-04 → none |
| 78 | Install chair rails, crown moldings, trim | 2018-03-01 → 2019-07-02 (+488d) | 2018-03-05 → 2019-07-04 (+486d) |  | 20.75d → 20d | baseline start 2017-01-04 → none; baseline finish 2017-01-06 → none |
| 79 | **Finish Plumbing** | 2018-02-27 → 2019-06-28 (+486d) | 2018-03-07 → 2019-07-08 (+488d) |  | 0.75d → 0d | baseline start 2017-01-02 → none; baseline finish 2017-01-10 → none |
| 80 | Complete 1st floor - kitchen plumbing | 2018-02-27 → 2019-06-28 (+486d) | 2018-02-28 → 2019-07-01 (+488d) |  | 0.75d → 0d | baseline start 2017-01-02 → none; baseline finish 2017-01-03 → none |
| 81 | Complete 1st floor - master bath and guest plumbing | 2018-02-28 → 2019-07-01 (+488d) | 2018-03-02 → 2019-07-03 (+488d) |  | 0.75d → 0d | baseline start 2017-01-03 → none; baseline finish 2017-01-05 → none |
| 82 | Complete 2nd floor - hall bath and private bath plumbing | 2018-03-02 → 2019-07-03 (+488d) | 2018-03-06 → 2019-07-05 (+486d) |  | 0.75d → 0d | baseline start 2017-01-05 → none; baseline finish 2017-01-09 → none |
| 83 | Conduct finish plumbing inspection | 2018-03-06 → 2019-07-05 (+486d) | 2018-03-07 → 2019-07-08 (+488d) |  | 0.75d → 0d | baseline start 2017-01-09 → none; baseline finish 2017-01-10 → none |
| 84 | **Finish Electrical** | 2018-03-06 → 2019-07-05 (+486d) | 2018-03-09 → 2019-07-10 (+488d) |  | 1.75d → 1d | baseline start 2017-01-09 → none; baseline finish 2017-01-12 → none |
| 85 | Complete 1st floor circuits to service panel | 2018-03-06 → 2019-07-05 (+486d) | 2018-03-07 → 2019-07-08 (+488d) |  | 3.75d → 3d | baseline start 2017-01-09 → none; baseline finish 2017-01-10 → none |
| 86 | Complete 2nd floor circuits to service panel | 2018-03-07 → 2019-07-08 (+488d) | 2018-03-08 → 2019-07-09 (+488d) |  | 3.75d → 3d | baseline start 2017-01-10 → none; baseline finish 2017-01-11 → none |
| 87 | Conduct finish electrical inspection | 2018-03-08 → 2019-07-09 (+488d) | 2018-03-09 → 2019-07-10 (+488d) |  | 3.75d → 3d | baseline start 2017-01-11 → none; baseline finish 2017-01-12 → none |
| 88 | Complete communications wiring - phone, cable, computer, alarm | 2018-03-07 → 2019-07-08 (+488d) | 2018-03-09 → 2019-07-10 (+488d) |  | 0.75d → 0d | baseline start 2017-01-10 → none; baseline finish 2017-01-12 → none |
| 89 | **Finish HVAC** | 2018-03-09 → 2019-07-10 (+488d) | 2018-03-14 → 2019-07-15 (+488d) |  | 0.75d → 0d | baseline start 2017-01-12 → none; baseline finish 2017-01-17 → none |
| 90 | Complete 1st floor - zone 1 HVAC | 2018-03-09 → 2019-07-10 (+488d) | 2018-03-12 → 2019-07-11 (+486d) |  | 0.75d → 0d | baseline start 2017-01-12 → none; baseline finish 2017-01-13 → none |
| 91 | Complete 2nd floor - zone 2 HVAC | 2018-03-12 → 2019-07-11 (+486d) | 2018-03-13 → 2019-07-12 (+486d) |  | 0.75d → 0d | baseline start 2017-01-13 → none; baseline finish 2017-01-16 → none |
| 92 | Conduct HVAC inspection | 2018-03-13 → 2019-07-12 (+486d) | 2018-03-14 → 2019-07-15 (+488d) |  | 0.75d → 0d | baseline start 2017-01-16 → none; baseline finish 2017-01-17 → none |
| 93 | **Carpet, Tile and Appliances** | 2018-03-14 → 2019-07-15 (+488d) | 2018-03-26 → 2019-07-25 (+486d) |  | 0.75d → 0d | baseline start 2017-01-17 → none; baseline finish 2017-01-27 → none |
| 94 | Tile entry, kitchen and baths | 2018-03-14 → 2019-07-15 (+488d) | 2018-03-19 → 2019-07-18 (+486d) |  | 0.75d → 0d | baseline start 2017-01-17 → none; baseline finish 2017-01-20 → none |
| 95 | Carpet 1st floor | 2018-03-19 → 2019-07-18 (+486d) | 2018-03-21 → 2019-07-22 (+488d) |  | 0.75d → 0d | baseline start 2017-01-20 → none; baseline finish 2017-01-24 → none |
| 96 | Carpet 2nd floor | 2018-03-21 → 2019-07-22 (+488d) | 2018-03-23 → 2019-07-24 (+488d) |  | 0.75d → 0d | baseline start 2017-01-24 → none; baseline finish 2017-01-26 → none |
| 97 | Install appliances | 2018-03-23 → 2019-07-24 (+488d) | 2018-03-26 → 2019-07-25 (+486d) |  | 0.75d → 0d | baseline start 2017-01-26 → none; baseline finish 2017-01-27 → none |
| 98 | **Landscaping and Grounds Work** | 2018-03-07 → 2019-07-08 (+488d) | 2018-04-02 → 2019-08-01 (+486d) |  | 0.75d → 0d | baseline start 2017-01-10 → none; baseline finish 2017-02-03 → none |
| 99 | Pour concrete driveway and sidewalks | 2018-03-07 → 2019-07-08 (+488d) | 2018-03-08 → 2019-07-09 (+488d) |  | 13.25d → 12.25d | baseline start 2017-01-10 → none; baseline finish 2017-01-11 → none |
| 100 | Install backyard fence | 2018-03-26 → 2019-07-25 (+486d) | 2018-03-28 → 2019-07-29 (+488d) |  | 0.75d → 0d | baseline start 2017-01-27 → none; baseline finish 2017-01-31 → none |
| 101 | Sod and complete plantings - front yard | 2018-03-28 → 2019-07-29 (+488d) | 2018-03-30 → 2019-07-31 (+488d) |  | 0.75d → 0d | baseline start 2017-01-31 → none; baseline finish 2017-02-02 → none |
| 102 | Sod and complete plantings - backyard | 2018-03-30 → 2019-07-31 (+488d) | 2018-04-02 → 2019-08-01 (+486d) |  | 0.75d → 0d | baseline start 2017-02-02 → none; baseline finish 2017-02-03 → none |
| 103 | **Final Acceptance** | 2018-04-02 → 2019-08-01 (+486d) | 2018-04-12 → 2019-08-13 (+488d) | 8.25d → 7.5d |  | baseline start 2017-02-03 → none; baseline finish 2017-02-14 → none |
| 104 | Complete final inspection for certificate of occupancy | 2018-04-02 → 2019-08-01 (+486d) | 2018-04-03 → 2019-08-02 (+486d) |  | 0.75d → 0d | baseline start 2017-02-03 → none; baseline finish 2017-02-06 → none |
| 105 | Cleanup for occupancy | 2018-04-03 → 2019-08-02 (+486d) | 2018-04-04 → 2019-08-05 (+488d) |  | 0.75d → 0d | baseline start 2017-02-06 → none; baseline finish 2017-02-07 → none |
| 106 | Perform final walk-through inspection | 2018-04-04 → 2019-08-05 (+488d) | 2018-04-05 → 2019-08-06 (+488d) |  | 0.75d → 0d | baseline start 2017-02-07 → none; baseline finish 2017-02-08 → none |
| 107 | Complete punch list items | 2018-04-06 → 2019-08-06 (+487d) | 2018-04-12 → 2019-08-13 (+488d) |  |  | constraint must finish on 2018-04-12 → none; baseline start 2017-02-08 → none; baseline finish 2017-02-14 → none |
